# JRA3-T1 WI 1.2 - Activity plan

How a schedule from MS Project changed from version to version. A marks actual dates.

## Version 1 (data date 2013-12-06, saved 2014-05-14)

| ID | WBS | Task | Duration | Start | Finish | Predecessors | Complete | Total float | Constraint |
| --- | --- | --- | --- | --- | --- | --- | --- | --- | --- |
| 1 | 1 | **Documentation phase** | 59d | 2014-01-06 A | 2014-03-27 |  | 90% | 37.5d |  |
| 2 |  | Documentation on Grouper | 59d | 2014-01-06 A | 2014-03-27 A |  | 100% |  |  |
| 3 |  | Documentation on CoManage (to externalize group management) | 17d | 2014-03-05 A | 2014-03-27 | 2FF | 40% | 26d |  |
| 4 |  | Documentation on Grouper integration with Shibboleth | 25d | 2014-02-21 A | 2014-03-27 A | 2FF | 100% |  |  |
| 5 | 2 | **Feasibility (14 month, by 30/05/2014)** | 35d | 2014-03-28 A | 2014-05-15 |  | 80% | 9.5d |  |
| 6 |  | Feasiblity report | 35d | 2014-03-28 A | 2014-05-15 | 1 | 80% | 9.5d |  |
| 7 |  | Feasibility milestone | 0d | 2014-05-15 | 2014-05-15 | 6 |  | 1.5d |  |
| 8 | 3 | **Design (18 month, by 30/09/1024)** | 80d | 2014-06-03 A | 2014-09-22 |  | 6% | 1.5d |  |
| 9 |  | Solution design and architecture definition | 80d | 2014-06-03 A | 2014-09-22 | 5FS+12d | 10% | 1.5d |  |
| 10 |  | Architecture for discovery | 60d | 2014-07-01 | 2014-09-22 | 9FF |  | 1.5d |  |
| 11 |  | Design milestone | 0d | 2014-09-22 | 2014-09-22 | 10 |  | 1.5d |  |
| 12 | 4 | **Build (21 month, by 31/12/2014)** | 64d | 2014-10-02 A | 2014-12-30 |  | 4% | 0d |  |
| 13 |  | Installation of a Grouper instance | 5d | 2014-10-02 | 2014-10-08 | 8FS+7d |  | 1.5d |  |
| 14 |  | Integration of Grouper with a Shibboleth IdP | 1d | 2014-10-09 | 2014-10-09 | 13 |  | 1.5d |  |
| 15 |  | Installation of CoManage | 5d | 2014-10-03 | 2014-10-09 | 13FF+8h |  | 1.5d |  |
| 16 |  | Configuration of Grouper as an Attribute Authority | 7d | 2014-10-10 | 2014-10-20 | 13, 14, 15 |  | 1.5d |  |
| 17 | 4.5 | **Integrate Grouper with a wiki SP** | 23d | 2014-10-21 | 2014-11-20 |  |  | 1.5d |  |
| 18 |  | Integration of Grouper with a Shibboleth SP | 2d | 2014-10-21 | 2014-10-22 | 16 |  | 1.5d |  |
| 19 |  | Modifications of the wiki application to manage Grouper groups | 21d | 2014-10-23 | 2014-11-20 | 18 |  | 1.5d |  |
| 20 | 4.6 | **Integrate Grouper with a moodle SP** | 17d | 2014-11-21 A | 2014-12-15 |  | 22% | 0d |  |
| 21 |  | Integration of Grouper with a Shibboleth SP | 1d | 2014-11-21 A | 2014-11-21 | 17 | 50% | 1d |  |
| 22 |  | Modifications of the moodle application to manage Grouper groups | 16d | 2014-11-24 A | 2014-12-15 | 21 | 20% | 0d |  |
| 23 | 4.7 | **Integrate Grouper with GARRbox SP** | 17d | 2014-11-24 | 2014-12-16 |  |  | 0d |  |
| 24 |  | Integration of Grouper with a Shibboleth SP | 1d | 2014-12-16 | 2014-12-16 | 20 |  | 0d |  |
| 25 |  | Modifications of the GARRbox application to manage Grouper groups | 16d | 2014-11-24 | 2014-12-15 | 21 |  | 1d |  |
| 26 |  | PoC documentation | 10d | 2014-12-17 | 2014-12-30 | 17, 20, 23 |  | 0d |  |
| 27 |  | Build milestone | 0d | 2014-12-30 | 2014-12-30 | 26 |  | 0d |  |
| 28 | 5 | **Finalize (24 month, by 31/03/2015)** | 105d | 2015-01-02 | 2015-05-28 |  |  | 0d |  |
| 29 |  | Deliverables for dissemination | 30d | 2015-01-02 | 2015-02-12 | 12FS+2d |  | 0d |  |
| 30 |  | Disseminate information | 60d | 2015-02-13 | 2015-05-07 | 29 |  | 0d |  |
| 31 |  | Project closure milestone | 0d | 2015-05-28 | 2015-05-28 | 30FS+15d |  | 0d | start no earlier than 2014-01-07 |

## Version 2 (data date 2013-12-06, saved 2014-11-18)

Last finish stays 2015-05-28. Complete tasks 2 → 12.

Removed: 3 Documentation on CoManage (to externalize group management); 15 Installation of CoManage

Changed:

| ID | Task | Start | Finish | Complete | Total float | Predecessors |
| --- | --- | --- | --- | --- | --- | --- |
| 1 | **Documentation phase** |  | 2014-03-27 A | 90% → 100% | 37.5d → none |  |
| 4 | **Feasibility (14 month, by 30/05/2014)** |  | 2014-05-15 A | 80% → 100% | 9.5d → none |  |
| 5 | Feasiblity report |  | 2014-05-15 A | 80% → 100% | 9.5d → none |  |
| 6 | Feasibility milestone | 2014-05-15 A | 2014-05-15 A | 0% → 100% | 1.5d → none |  |
| 7 | **Design (18 month, by 30/09/1024)** |  |  | 6% → 91% | 1.5d → 178d |  |
| 8 | Solution design and architecture definition |  | 2014-09-22 A | 10% → 100% | 1.5d → none |  |
| 9 | Architecture for discovery | 2014-07-01 A |  | 0% → 80% | 1.5d → 178d |  |
| 11 | **Build (21 month, by 31/12/2014)** |  |  | 4% → 70% |  |  |
| 12 | Installation of a Grouper instance | 2014-10-02 A | 2014-10-08 A | 0% → 100% | 1.5d → none |  |
| 13 | Integration of Grouper with a Shibboleth IdP | 2014-10-09 A | 2014-10-09 A | 0% → 100% | 1.5d → none |  |
| 14 | Configuration of Grouper as an Attribute Authority | 2014-10-10 A | 2014-10-20 A | 0% → 100% | 1.5d → none | 12, 13, Installation of CoManage → 12, 13 |
| 15 | **Integrate Grouper with a wiki SP** | 2014-10-21 A | 2014-11-20 A | 0% → 100% | 1.5d → none |  |
| 16 | Integration of Grouper with a Shibboleth SP | 2014-10-21 A | 2014-10-22 A | 0% → 100% | 1.5d → none |  |
| 17 | Modifications of the wiki application to manage Grouper groups | 2014-10-23 A | 2014-11-20 A | 0% → 100% | 1.5d → none |  |
| 18 | **Integrate Grouper with a moodle SP** |  | 2014-12-15 A | 22% → 100% | 0d → none |  |
| 19 | Integration of Grouper with a Shibboleth SP |  | 2014-11-21 A | 50% → 100% | 1d → none |  |
| 20 | Modifications of the moodle application to manage Grouper groups |  | 2014-12-15 A | 20% → 100% | 0d → none |  |
| 21 | **Integrate Grouper with GARRbox SP** | 2014-11-24 A |  | 0% → 1% | 0d → 3d |  |
| 22 | Integration of Grouper with a Shibboleth SP | 2014-12-16 A |  | 0% → 10% | 0d → 3d |  |
| 24 | PoC documentation | 2014-12-17 A |  | 0% → 30% |  |  |
